# V2 Halls of Residence Fit Out 05 Oct 2023

Schedule from MS Project, 2024-02-05 to 2024-09-02.

## Calendars

- Standard: Mon-Fri 08:00-12:00, 13:00-17:00; Sat-Sun off.

## Schedule

| ID | WBS | Task | Duration | Start | Finish | Predecessors | Total slack | Free slack | Constraint |
| --- | --- | --- | --- | --- | --- | --- | --- | --- | --- |
| 1 | 1 | **REFURBISHMENT WORKS TO PATWORTH HALL** | 49d | 2024-02-05 | 2024-04-11 |  | -49d | 0d |  |
| 2 | 1.1 | Enabling Works/site set up | 4d | 2024-02-05 | 2024-02-08 |  | -49d | 0d | start no earlier than 2024-02-05 |
| 3 | 1.2 | Isolate & Strip out Patworth Hall | 10d | 2024-02-05 | 2024-02-16 | 2SS | -49d | 0d |  |
| 4 | 1.3 | Break up Screed | 6d | 2024-02-08 | 2024-02-15 | 3SS+3d | -49d | 0d |  |
| 5 | 1.4 | Widen Door ways | 6d | 2024-02-13 | 2024-02-20 | 4SS+3d | -49d | 0d |  |
| 6 | 1.5 | Remove and install new windows | 10d | 2024-02-21 | 2024-03-05 | 3, 4, 5 | -49d | 0d |  |
| 7 | 1.6 | 1st Fix Elec | 10d | 2024-02-21 | 2024-03-05 | 3, 4, 5 | -49d | 0d |  |
| 8 | 1.7 | 1st Fix Plumbing | 12d | 2024-02-23 | 2024-03-11 | 7SS+2d | -48d | 0d |  |
| 9 | 1.8 | Flooring | 8d | 2024-03-15 | 2024-03-26 | 11FS-3d | -49d | 0d |  |
| 10 | 1.9 | Doors | 8d | 2024-03-12 | 2024-03-21 | 6, 7, 8 | 117d |  |  |
| 11 | 1.10 | Walling - board; insulate and skim | 10d | 2024-03-06 | 2024-03-19 | 6, 7, 8FS-5d | -49d | 0d |  |
| 12 | 1.11 | Plaster/Skim and Decoration | 15d | 2024-03-13 | 2024-04-02 | 11SS+5d | -43d | 0d |  |
| 13 | 1.12 | Fixed Furniture | 10d | 2024-03-27 | 2024-04-09 | 9, 11 | -49d | 0d |  |
| 14 | 1.13 | Kitchen & Living Area | 5d | 2024-03-27 | 2024-04-02 | 9 | 109d |  |  |
| 15 | 1.14 | 2nd fix Elec | 6d | 2024-03-27 | 2024-04-03 | 7, 11, 12FS-5d | -43d | 0d |  |
| 16 | 1.15 | 2nd fix plumb | 5d | 2024-04-05 | 2024-04-11 | 8, 13FS-3d | -49d | 0d |  |
| 17 | 1.16 | Commission; test & witness | 5d | 2024-04-05 | 2024-04-11 | 16FF, 15FF | -49d | 0d |  |
| 18 | 1.17 | Clean & handover | 4d | 2024-04-08 | 2024-04-11 | 17FF | -49d | 0d |  |
| 19 | 2 | **REFURBISHMENT WORKS TO ONGLEY HALL** | 49d | 2024-04-12 | 2024-06-19 |  | -49d | 0d |  |
| 20 | 2.1 | Enabling Works/site set up | 4d | 2024-04-12 | 2024-04-17 | 18 | -49d | 0d | start no earlier than 2024-02-05 |
| 21 | 2.2 | Isolate & Strip out Ongley Hall | 10d | 2024-04-12 | 2024-04-25 | 20SS | -49d | 0d |  |
| 22 | 2.3 | Break up Screed | 6d | 2024-04-17 | 2024-04-24 | 21SS+3d | -49d | 0d |  |
| 23 | 2.4 | Widen Door ways | 6d | 2024-04-22 | 2024-04-29 | 22SS+3d | -49d | 0d |  |
| 24 | 2.5 | Remove and install new windows | 10d | 2024-04-30 | 2024-05-13 | 21, 22, 23 | -49d | 0d |  |
| 25 | 2.6 | 1st Fix Elec | 10d | 2024-04-30 | 2024-05-13 | 21, 22, 23 | -49d | 0d |  |
| 26 | 2.7 | 1st Fix Plumbing | 12d | 2024-05-02 | 2024-05-17 | 25SS+2d | -48d | 0d |  |
| 27 | 2.8 | Flooring | 8d | 2024-05-23 | 2024-06-03 | 29FS-3d | -49d | 0d |  |
| 28 | 2.9 | Doors | 8d | 2024-05-20 | 2024-05-29 | 24, 25, 26 | 68d |  |  |
| 29 | 2.10 | Walling - board; insulate and skim | 10d | 2024-05-14 | 2024-05-27 | 24, 25, 26FS-5d | -49d | 0d |  |
| 30 | 2.11 | Plaster/Skim and Decoration | 15d | 2024-05-21 | 2024-06-10 | 29SS+5d | -43d | 0d |  |
| 31 | 2.12 | Fixed Furniture | 10d | 2024-06-04 | 2024-06-17 | 27, 29 | -49d | 0d |  |
| 32 | 2.13 | Kitchen & Living Area | 5d | 2024-06-04 | 2024-06-10 | 27 | 60d |  |  |
| 33 | 2.14 | 2nd fix Elec | 6d | 2024-06-04 | 2024-06-11 | 25, 29, 30FS-5d | -43d | 0d |  |
| 34 | 2.15 | 2nd fix plumb | 5d | 2024-06-13 | 2024-06-19 | 26, 31FS-3d | -49d | 0d |  |
| 35 | 2.16 | Commission; test & witness | 5d | 2024-06-13 | 2024-06-19 | 33FF, 34FF | -49d | 0d |  |
| 36 | 2.17 | Clean & handover | 4d | 2024-06-14 | 2024-06-19 | 35FF | -49d | 0d | finish no earlier than 2024-06-19 |

| ID | WBS | Task | Duration | Start | Finish | Predecessors | Total slack | Free slack | Constraint |
| --- | --- | --- | --- | --- | --- | --- | --- | --- | --- |
| 37 | 3 | **REFURBISHMENT WORKS TO MILNER HALL** | 49d | 2024-06-20 | 2024-08-27 |  | -49d | 0d |  |
| 38 | 3.1 | Enabling Works/site set up | 4d | 2024-06-20 | 2024-06-25 | 36 | -49d | 0d | start no earlier than 2024-02-05 |
| 39 | 3.2 | Isolate & Strip out Ongley Halls | 10d | 2024-06-20 | 2024-07-03 | 38SS | -49d | 0d |  |
| 40 | 3.3 | Break up Screed | 6d | 2024-06-25 | 2024-07-02 | 39SS+3d | -49d | 0d |  |
| 41 | 3.4 | Widen Door ways | 6d | 2024-06-28 | 2024-07-05 | 40SS+3d | -49d | 0d |  |
| 42 | 3.5 | Remove and install new windows | 10d | 2024-07-08 | 2024-07-19 | 39, 40, 41 | -49d | 0d |  |
| 43 | 3.6 | 1st Fix Elec | 10d | 2024-07-08 | 2024-07-19 | 39, 40, 41 | -49d | 0d |  |
| 44 | 3.7 | 1st Fix Plumbing | 12d | 2024-07-10 | 2024-07-25 | 43SS+2d | -48d | 0d |  |
| 45 | 3.8 | Flooring | 8d | 2024-07-31 | 2024-08-09 | 47FS-3d | -49d | 0d |  |
| 46 | 3.9 | Doors | 8d | 2024-07-26 | 2024-08-06 | 42, 43, 44 | 19d |  |  |
| 47 | 3.10 | Walling - board; insulate and skim | 10d | 2024-07-22 | 2024-08-02 | 42, 43, 44FS-5d | -49d | 0d |  |
| 48 | 3.11 | Plaster/Skim and Decoration | 15d | 2024-07-29 | 2024-08-16 | 47SS+5d | -43d | 0d |  |
| 49 | 3.12 | Fixed Furniture | 10d | 2024-08-12 | 2024-08-23 | 45, 47 | -49d | 0d |  |
| 50 | 3.13 | Kitchen & Living Area | 5d | 2024-08-12 | 2024-08-16 | 45 | 11d |  |  |
| 51 | 3.14 | 2nd fix Elec | 6d | 2024-08-12 | 2024-08-19 | 43, 47, 48FS-5d | -43d | 0d |  |
| 52 | 3.15 | 2nd fix plumb | 5d | 2024-08-21 | 2024-08-27 | 44, 49FS-3d | -49d | 0d |  |
| 53 | 3.16 | Commission; test & witness | 5d | 2024-08-21 | 2024-08-27 | 51FF, 52FF | -49d | 0d |  |
| 54 | 3.17 | Clean & handover | 4d | 2024-08-22 | 2024-08-27 | 53FF | -49d | 0d |  |
| 55 | 4 | Complete Patworth & Ongley | 1d | 2024-06-20 | 2024-06-20 | 54 | -49d | 0d | must finish on 2024-06-20 |
| 56 | 5 | **REFURBISHMENT WORKS TO CLAYTON HALL** | 49d | 2024-06-20 | 2024-08-27 |  | 0d |  |  |
| 57 | 5.1 | Enabling Works/site set up | 4d | 2024-06-20 | 2024-06-25 | 36 | 0d |  |  |
| 58 | 5.2 | Isolate & Strip out Clayton Halls | 10d | 2024-06-20 | 2024-07-03 | 57SS | 0d |  |  |
| 59 | 5.3 | Break up Screed | 6d | 2024-06-25 | 2024-07-02 | 58SS+3d | 3d | 0d |  |
| 60 | 5.4 | Widen Door ways | 6d | 2024-06-28 | 2024-07-05 | 59SS+3d | 3d | 0d |  |
| 61 | 5.5 | Remove and install new windows | 10d | 2024-07-08 | 2024-07-19 | 58, 59, 60 | 3d | 0d |  |
| 62 | 5.6 | 1st Fix Elec | 10d | 2024-07-08 | 2024-07-19 | 58, 59, 60 | 3d | 0d |  |
| 63 | 5.7 | 1st Fix Plumbing | 12d | 2024-07-10 | 2024-07-25 | 62SS+2d | 4d | 0d |  |
| 64 | 5.8 | Flooring | 8d | 2024-07-31 | 2024-08-09 | 66FS-3d | 3d | 0d |  |
| 65 | 5.9 | Doors | 8d | 2024-07-26 | 2024-08-06 | 61, 62, 63 | 19d |  |  |
| 66 | 5.10 | Walling - board; insulate and skim | 10d | 2024-07-22 | 2024-08-02 | 61, 62, 63FS-5d | 3d | 0d |  |
| 67 | 5.11 | Plaster/Skim and Decoration | 15d | 2024-07-29 | 2024-08-16 | 66SS+5d | 9d | 0d |  |
| 68 | 5.12 | Fixed Furniture | 10d | 2024-08-12 | 2024-08-23 | 64, 66 | 3d | 0d |  |
| 69 | 5.13 | Kitchen & Living Area | 5d | 2024-08-12 | 2024-08-16 | 64 | 11d |  |  |
| 70 | 5.14 | 2nd fix Elec | 6d | 2024-08-12 | 2024-08-19 | 62, 66, 67FS-5d | 9d | 6d |  |
| 71 | 5.15 | 2nd fix plumb | 5d | 2024-08-21 | 2024-08-27 | 63, 68FS-3d | 3d | 0d |  |
| 72 | 5.16 | Commission; test & witness | 5d | 2024-08-21 | 2024-08-27 | 70FF, 71FF | 3d | 0d |  |
| 73 | 5.17 | Clean & handover | 4d | 2024-08-22 | 2024-08-27 | 72FF | 3d | 2d |  |

| ID | WBS | Task | Type | Duration | Start | Finish | Predecessors | Total slack | Free slack | Constraint |
| --- | --- | --- | --- | --- | --- | --- | --- | --- | --- | --- |
| 74 | 6 | **REFURBISHMENT WORKS TO EDMUND HALL** |  | 49d | 2024-06-24 | 2024-08-29 |  | 0d |  |  |
| 75 | 6.1 | Enabling Works/site set up |  | 4d | 2024-06-24 | 2024-06-27 | 36 | 0d |  | must start on 2024-06-24 |
| 76 | 6.2 | Isolate & Strip out Edmund Hall |  | 10d | 2024-06-24 | 2024-07-05 | 75SS | 1d | 0d |  |
| 77 | 6.3 | Break up Screed |  | 6d | 2024-06-27 | 2024-07-04 | 76SS+3d | 1d | 0d |  |
| 78 | 6.4 | Widen Door ways |  | 6d | 2024-07-02 | 2024-07-09 | 77SS+3d | 1d | 0d |  |
| 79 | 6.5 | Remove and install new windows |  | 10d | 2024-07-10 | 2024-07-23 | 76, 77, 78 | 1d | 0d |  |
| 80 | 6.6 | 1st Fix Elec |  | 10d | 2024-07-10 | 2024-07-23 | 76, 77, 78 | 1d | 0d |  |
| 81 | 6.7 | 1st Fix Plumbing |  | 12d | 2024-07-12 | 2024-07-29 | 80SS+2d | 2d | 0d |  |
| 82 | 6.8 | Flooring |  | 8d | 2024-08-02 | 2024-08-13 | 84FS-3d | 1d | 0d |  |
| 83 | 6.9 | Doors |  | 8d | 2024-07-30 | 2024-08-08 | 79, 80, 81 | 17d |  |  |
| 84 | 6.10 | Walling - board; insulate and skim |  | 10d | 2024-07-24 | 2024-08-06 | 79, 80, 81FS-5d | 1d | 0d |  |
| 85 | 6.11 | Plaster/Skim and Decoration |  | 15d | 2024-07-31 | 2024-08-20 | 84SS+5d | 7d | 0d |  |
| 86 | 6.12 | Fixed Furniture |  | 10d | 2024-08-14 | 2024-08-27 | 82, 84 | 1d | 0d |  |
| 87 | 6.13 | Kitchen & Living Area |  | 5d | 2024-08-14 | 2024-08-20 | 82 | 9d |  |  |
| 88 | 6.14 | 2nd fix Elec |  | 6d | 2024-08-14 | 2024-08-21 | 80, 84, 85FS-5d | 7d | 6d |  |
| 89 | 6.15 | 2nd fix plumb |  | 5d | 2024-08-23 | 2024-08-29 | 81, 86FS-3d | 1d | 0d |  |
| 90 | 6.16 | Commission; test & witness |  | 5d | 2024-08-23 | 2024-08-29 | 88FF, 89FF | 1d | 0d |  |
| 91 | 6.17 | Clean & handover |  | 4d | 2024-08-26 | 2024-08-29 | 90FF | 1d | 0d |  |
| 92 | 7 | Complete Halls of Residence Refurbishment | milestone | 0d | 2024-08-29 | 2024-08-29 | 91, 73 | 2d |  |  |
| 93 | 8 | **SALIX ROOF INSULATION WORKS** |  | 96d | 2024-02-09 | 2024-06-21 |  | 50d |  |  |
| 94 | 8.1 | Set up Scaffolding Access to Block 1 |  | 5d | 2024-02-09 | 2024-02-15 | 2 | 50d | 0d |  |
| 95 | 8.2 | Set up Scaffolding Access to Block 2 plus common room |  | 5d | 2024-02-16 | 2024-02-22 | 94 | 70d | 20d |  |
| 96 | 8.3 | Set up Scaffolding Access to Russell Hall |  | 5d | 2024-02-16 | 2024-02-22 | 94 | 100d | 50d |  |
| 97 | 8.4 | Set up Scaffolding Access to LRC/IT Block |  | 7d | 2024-02-16 | 2024-02-26 | 94 | 98d | 48d |  |
| 98 | 8.5 | Roofing works Block 1 |  | 20d | 2024-02-16 | 2024-03-14 | 94 | 50d | 0d |  |
| 99 | 8.6 | Roofing works Block 2 & Common Room |  | 30d | 2024-03-15 | 2024-04-25 | 98, 95FS-5d | 50d | 0d |  |
| 100 | 8.7 | Roofing Works to Russell Hall |  | 41d | 2024-04-26 | 2024-06-21 | 99, 96FS-5d | 50d |  |  |
| 101 | 8.8 | Roofing works to LRC/ITC |  | 41d | 2024-04-26 | 2024-06-21 | 99, 97FS-5d | 50d |  |  |

| ID | WBS | Task | Duration | Start | Finish | Predecessors | Total slack | Free slack | Constraint |
| --- | --- | --- | --- | --- | --- | --- | --- | --- | --- |
| 102 | 9 | **Whole Campus SALIX Works** | 126d? | 2024-03-11 | 2024-09-02 |  | 0d |  |  |
| 103 | 9.1 | Enabling Works for plant room & ASHP | 15d | 2024-03-11 | 2024-03-29 |  | 3d | 0d | start no earlier than 2024-03-11 |
| 104 | 9.2 | Deliver Buffer Vessel & ASHP | 1d | 2024-04-01 | 2024-04-01 | 103 | 65d | 0d |  |
| 105 | 9.3 | Erect Plant Room | 15d | 2024-04-01 | 2024-04-19 | 103 | 66d | 0d |  |
| 106 | 9.4 | Install new heating pipework network | 30d | 2024-04-01 | 2024-05-10 | 103 | 3d | 0d |  |
| 107 | 9.5 | Install new substation | 15d | 2024-04-02 | 2024-04-22 | 104 | 65d | 0d |  |
| 108 | 9.6 | Plantroom First Fix | 20d | 2024-04-22 | 2024-05-17 | 105 | 76d |  |  |
| 109 | 9.7 | Plantroom Second Fix | 30d | 2024-04-23 | 2024-06-03 | 105, 107 | 65d |  |  |
| 110 | 9.8 | BWIC | 20d | 2024-04-15 | 2024-05-10 | 106FF | 81d |  |  |
| 111 | 9.9 | First Fix SALIX Works Russell Hall | 30d | 2024-05-13 | 2024-06-21 | 106 | 10d | 0d |  |
| 112 | 9.10 | Second Fix SALIX Works Russell Hall | 20d | 2024-06-24 | 2024-07-19 | 111 | 10d | 0d |  |
| 113 | 9.11 | First Fix SALIX Works LRC/ITC | 15d | 2024-05-13 | 2024-05-31 | 106 | 3d | 0d |  |
| 114 | 9.12 | Second Fix SALIX Works LRC/ITC | 20d | 2024-06-03 | 2024-06-28 | 113 | 3d |  |  |
| 115 | 9.13 | Halls of Residence Plantroom Works | 35d | 2024-07-04 | 2024-08-21 | 114, 58 | 0d |  |  |
| 116 | 9.14 | Commissioning [Halls Plantroom] | 5d | 2024-08-22 | 2024-08-28 | 115 | 0d |  |  |
| 117 | 9.15 | Witnessing [Halls Plantroom] | 2d | 2024-08-29 | 2024-08-30 | 116 | 0d |  |  |
| 118 | 9.16 | Connections to Halls | 10d | 2024-05-13 | 2024-05-24 | 106 | 71d |  |  |
| 119 | 9.17 | New electrical supply Milner | 10d | 2024-04-04 | 2024-04-17 | 15 | 98d |  |  |
| 120 | 9.18 | Commissioning | 15d | 2024-07-22 | 2024-08-09 | 112, 114 | 10d | 0d |  |
| 121 | 9.19 | Witness | 5d | 2024-08-12 | 2024-08-16 | 120 | 10d |  |  |
| 123 | 9.20 | Completion of Entire SALIX/Refurbishment Works | 1d? | 2024-09-02 | 2024-09-02 | 98, 99, 100, 101, 91, 73, 121, 117 | 0d |  |  |
