# New Project1(SB)

Schedule from MS Project, 2017-01-03 to 2018-11-16.
NML

## Calendars

- Standard: Mon-Fri 09:00-12:00, 13:00-17:00; Sat-Sun off. Exceptions (off unless hours are given): 2017-10-29, 2017-12-22 08:00-12:00, 13:00-17:00, 2017-12-25 to 2017-12-29, 2018-01-01 to 2018-01-02, 2018-01-20 08:00-12:00, 13:00-17:00, 2018-10-27 to 2018-10-28 08:00-12:00, 13:00-17:00.

## Resources

| Resource |
| --- |
| Mark |
| Mike |
| Rich |
| Simon |
| John |
| Mark - unplaced |
| Unplaced |
| Unplaced - on hold |
| ? |
| Outsourced |
| - Marketing brief due 02/04/14 - Sign off 06/05/14 |
| - Mike |
| - M&C brief due 02/04/14 - Sign off 06/05/14 |
| - M&C brief due 15/04/14 - Sign off 09/6/14 |
| - M&C brief due 28/04/14 - sign off 30/05/14 |
| out |
| Lee |
| Dave |

## Schedule

| ID | WBS | Task | Type | Duration | Start | Finish | Total slack | Constraint |
| --- | --- | --- | --- | --- | --- | --- | --- | --- |
| 1 | 1 | Provisional object list agreed | milestone | 0.88d? | 2017-01-31 | 2017-01-31 | 406.5d | start no earlier than 2017-01-31 |
| 2 | 2 | Object detail / dimensions required | milestone | 0.88d? | 2017-02-24 | 2017-02-24 | 390.75d | start no earlier than 2017-02-24 |
| 3 | 3 | **Stage 1 design (Scheme)** |  | 60.38d? | 2017-01-03 | 2017-04-07 | 364.5d |  |
| 4 | 3.1 | Identify main storylines / themes |  | 34.12d? | 2017-01-03 | 2017-02-24 | 390.75d | start no earlier than 2017-01-03 |
| 5 | 3.2 | Identify key object / groupings |  | 34.12d? | 2017-01-03 | 2017-02-24 | 390.75d | finish no earlier than 2017-02-24 |
| 6 | 3.3 | Identify key images / film |  | 34.12d? | 2017-01-03 | 2017-02-24 | 390.75d | finish no earlier than 2017-02-24 |
| 7 | 3.4 | Develop initial design ideas |  | 56d? | 2017-01-03 | 2017-03-31 | 368.88d | start no earlier than 2017-01-03 |
| 8 | 3.5 | Sign off scheme design |  | 4.38d? | 2017-04-03 | 2017-04-07 | 364.5d | start no earlier than 2017-04-03 |
| 9 | 4 | **Stage 2 design (Detail)** |  | 96.25d? | 2017-04-03 | 2017-09-01 | 272.62d |  |
| 10 | 4.1 | Main section text produced |  | 17.5d? | 2017-04-03 | 2017-04-28 | 351.38d | start no earlier than 2017-04-03 |
| 11 | 4.2 | Sign off exhibition narrative |  | 4.38d? | 2017-05-01 | 2017-05-05 | 347d | start no earlier than 2017-05-01 |
| 12 | 4.3 | Revise object list |  | 17.5d? | 2017-04-03 | 2017-04-28 | 351.38d | start no earlier than 2017-04-03 |
| 13 | 4.4 | List proposed images / film |  | 17.5d? | 2017-04-03 | 2017-04-28 | 351.38d | start no earlier than 2017-04-03 |
| 14 | 4.5 | Identify interactive elements |  | 17.5d? | 2017-04-03 | 2017-04-28 | 351.38d | start no earlier than 2017-04-03 |
| 15 | 4.6 | Develop design proposals |  | 35d? | 2017-04-03 | 2017-05-26 | 333.88d | finish no earlier than 2017-05-26 |
| 16 | 4.7 | Marketing campaign lead creative agreed |  | 4.38d? | 2017-05-01 | 2017-05-05 | 347d | start no earlier than 2017-05-01 |
| 17 | 4.8 | Marketing design period |  | 39.38d? | 2017-05-01 | 2017-06-30 | 312d | start no earlier than 2017-05-01 |
| 18 | 4.9 | Detail design drawings prepared |  | 56d? | 2017-06-05 | 2017-08-31 | 273.5d | start no earlier than 2017-06-05 |
| 19 | 4.10 | Label text produced |  | 17.5d? | 2017-07-03 | 2017-07-28 | 294.5d | start no earlier than 2017-07-03 |
| 20 | 4.11 | Sign off detail design |  | 4.38d? | 2017-08-28 | 2017-09-01 | 272.62d | start no earlier than 2017-08-28 |
| 21 | 5 | LHS decoration & remedial works |  | 7d? | 2017-04-24 | 2017-05-03 | 348.75d | start no earlier than 2017-04-24 |
| 22 | 6 | Bug House partial decant |  | 7d? | 2017-04-24 | 2017-05-03 | 348.75d | start no earlier than 2017-04-24 |
| 23 | 7 | Shaanxi Delegation inspection visit | milestone | 0.88d? | 2017-05-04 | 2017-05-04 | 347.88d | start no earlier than 2017-05-04 |
| 24 | 8 | Community engagement programme starts | milestone | 0.88d? | 2017-07-03 | 2017-07-03 | 311.12d | start no earlier than 2017-07-03 |
| 25 | 9 | Formal approval of loan request |  | 4.38d? | 2017-07-03 | 2017-07-07 | 307.62d | start no earlier than 2017-07-03 |
| 26 | 10 | Sign contract |  | 4.38d? | 2017-07-03 | 2017-07-07 | 307.62d | start no earlier than 2017-07-03 |
| 27 | 11 | Contract agreement with ticket sales provider |  | 17.5d? | 2017-07-03 | 2017-07-28 | 294.5d | start no earlier than 2017-07-03 |
| 28 | 12 | Recruit sales team |  | 17.5d? | 2017-07-03 | 2017-07-28 | 294.5d | start no earlier than 2017-07-03 |
| 29 | 13 | Identify key merchandising objects & images |  | 38.5d? | 2017-07-03 | 2017-08-31 | 273.5d | start no earlier than 2017-07-03 |
| 30 | 14 | Approval of shop merchandise |  | 35d? | 2017-08-07 | 2017-09-29 | 255.12d | start no earlier than 2017-08-07 |
| 31 | 15 | Transport tender period |  | 16.62d? | 2017-08-07 | 2017-08-31 | 273.5d | start no earlier than 2017-08-07 |
| 32 | 16 | Agent appointed |  | 17.5d? | 2017-09-04 | 2017-09-29 | 255.12d | start no earlier than 2017-09-04 |
| 33 | 17 | Schools programme finalised & advertised | milestone | 0.88d? | 2017-08-31 | 2017-08-31 | 273.5d | start no earlier than 2017-08-31 |
| 34 | 18 | China visit to assess mount requirements |  | 8.75d? | 2017-09-04 | 2017-09-15 | 263.88d | start no earlier than 2017-09-04 |
| 35 | 19 | Exhibition tickets go on sale | milestone | 0.88d? | 2017-09-04 | 2017-09-04 | 271.75d | start no earlier than 2017-09-04 |
| 36 | 20 | Public programme finalised & advertised | milestone | 0.88d? | 2017-09-29 | 2017-09-29 | 255.12d | start no earlier than 2017-09-29 |
| 37 | 21 | Exhibition build tender period |  | 17.5d? | 2017-09-04 | 2017-09-29 | 255.12d | start no earlier than 2017-09-04 |
| 38 | 22 | LHS gallery painted |  | 13.12d? | 2017-10-02 | 2017-10-20 | 242d | start no earlier than 2017-10-02 |
| 39 | 23 | Exhibition build and electrical works |  | 52.62d? | 2017-10-02 | 2017-12-22 | 202.5d | start no earlier than 2017-10-02 |
| 40 | 24 | Exhibition shop fit-out |  | 52.62d? | 2017-10-02 | 2017-12-22 | 202.5d | start no earlier than 2017-10-02 |
| 41 | 25 | Build complete | milestone | 0d? | 2017-12-22 | 2017-12-22 | 203.38d | start no earlier than 2017-12-22 |
| 43 | 26 | NML couriers travel to China | milestone | 0.88d | 2018-01-03 | 2018-01-03 | 201.62d | finish no earlier than 2018-01-03 |
| 44 | 27 | Objects condition checked & packed |  | 5.25d? | 2018-01-05 | 2018-01-12 | 195.5d | finish no earlier than 2018-01-12 |
| 45 | 28 | Object hand over / transported |  | 7.12d? | 2018-01-12 | 2018-01-22 | 189.25d | start no earlier than 2018-01-12 |
| 46 | 29 | Objects arrive at WML | milestone | 0.88d? | 2018-01-22 | 2018-01-22 | 189.25d | start no earlier than 2018-01-22 |
| 47 | 30 | Object installation |  | 8.75d? | 2018-01-22 | 2018-02-02 | 181.38d | start no earlier than 2018-01-22 |
| 48 | 31 | Ticket sales area installed |  | 4.38d? | 2018-02-05 | 2018-02-09 | 177d | start no earlier than 2018-02-05 |
| 49 | 32 | Exhibition media call / launch |  | 4.38d? | 2018-02-05 | 2018-02-09 | 177d | start no earlier than 2018-02-05 |
| 50 | 33 | Chinese officials to attend opening events |  | 5.25d? | 2018-02-06 | 2018-02-13 | 175.25d | start no earlier than 2018-02-06 |
| 51 | 34 | Exhibition private view | milestone | 0.88d? | 2018-02-08 | 2018-02-08 | 177.88d | start no earlier than 2018-02-08 |
| 52 | 35 | EXHIBITION OPENS | milestone | 0.88d? | 2018-02-09 | 2018-02-09 | 177d | start no earlier than 2018-02-09 |
| 53 | 36 | Exhibition run |  | 164.75d? | 2018-02-09 | 2018-10-28 | 13.12d | finish no earlier than 2018-10-28 |
| 54 | 37 | Academic exchange visit |  | 161.88d? | 2018-02-12 | 2018-10-26 | 15.12d | start no earlier than 2018-02-12 |
| 55 | 38 | EXHIBITION CLOSES | milestone | 0.88d? | 2018-10-28 | 2018-10-28 | 13.12d | finish no earlier than 2018-10-28 |
| 56 | 39 | Exhibition de-install |  | 8.75d? | 2018-10-29 | 2018-11-09 | 4.38d | start no earlier than 2018-10-29 |
| 57 | 40 | Objects returned to China |  | 4.38d? | 2018-11-12 | 2018-11-16 | 0d | finish no earlier than 2018-11-16 |

| ID | WBS | Task | Type | Duration | Start | Finish | Total slack | Constraint |
| --- | --- | --- | --- | --- | --- | --- | --- | --- |
| 59 | 41 | **Exhibition catalogue** |  | 228.62d? | 2017-01-27 | 2018-02-05 | 180.5d |  |
| 60 | 41.1 | Image selection |  | 77.88d? | 2017-01-27 | 2017-05-31 | 331.25d | finish no earlier than 2017-05-31 |
| 61 | 41.2 | Work on catalogue |  | 35d? | 2017-06-05 | 2017-07-28 | 294.5d | start no earlier than 2017-06-05 |
| 62 | 41.3 | First draft sent for proofing |  | 20.12d? | 2017-08-01 | 2017-08-31 | 273.5d | start no earlier than 2017-08-01 |
| 63 | 41.4 | First revisions |  | 17.5d? | 2017-09-04 | 2017-09-29 | 255.12d | start no earlier than 2017-09-04 |
| 64 | 41.5 | Second revisions |  | 17.5d? | 2017-10-02 | 2017-10-27 | 237.62d | start no earlier than 2017-10-02 |
| 65 | 41.6 | Catalogue sign off |  | 16.62d? | 2017-11-06 | 2017-11-30 | 216.62d | finish no earlier than 2017-11-30 |
| 66 | 41.7 | Production |  | 17.62d? | 2017-12-04 | 2018-01-09 | 198.12d | start no earlier than 2017-12-04 |
| 67 | 41.8 | Delivery to NML | milestone | 0.88d? | 2018-02-05 | 2018-02-05 | 180.5d | finish no earlier than 2018-02-05 |
| 69 | 42 | **Fundraising campaign** |  | 21.88d? | 2017-04-18 | 2017-05-22 | 337.38d |  |
| 70 | 42.1 | **Video / Web** |  | 21.88d? | 2017-04-18 | 2017-05-22 | 337.38d |  |
| 71 | 42.1.1 | Storyboard / key messages sign off | milestone | 0.88d? | 2017-04-18 | 2017-04-18 | 358.38d | start no earlier than 2017-04-18 |
| 72 | 42.1.2 | Brief sign off | milestone | 0.88d? | 2017-04-18 | 2017-04-18 | 358.38d | start no earlier than 2017-04-18 |
| 73 | 42.1.3 | Appoint video maker | milestone | 0.88d? | 2017-04-25 | 2017-04-25 | 354d | start no earlier than 2017-04-25 |
| 74 | 42.1.4 | Filming period |  | 7.88d? | 2017-05-03 | 2017-05-15 | 341.75d | finish no earlier than 2017-05-15 |
| 75 | 42.1.5 | View first video rushes | milestone | 0.88d? | 2017-05-09 | 2017-05-09 | 345.25d | start no earlier than 2017-05-09 |
| 76 | 42.1.6 | Comments and amends | milestone | 0.88d? | 2017-05-15 | 2017-05-15 | 341.75d | start no earlier than 2017-05-15 |
| 77 | 42.1.7 | Layout website pages |  | 5.25d? | 2017-05-15 | 2017-05-22 | 337.38d | start no earlier than 2017-05-15 |
| 78 | 42.2 | **Print material - brochure / leaflet** |  | 18.38d? | 2017-04-24 | 2017-05-22 | 337.38d |  |
| 79 | 42.2.1 | Text submitted and proofed |  | 1.75d? | 2017-04-24 | 2017-04-25 | 354d | finish no earlier than 2017-04-25 |
| 80 | 42.2.2 | Images sourced | milestone | 0.88d? | 2017-04-26 | 2017-04-26 | 353.12d | start no earlier than 2017-04-26 |
| 81 | 42.2.3 | Design period |  | 10.5d? | 2017-04-26 | 2017-05-11 | 343.5d | finish no earlier than 2017-05-11 |
| 82 | 42.2.4 | Comment and amends | milestone | 0.88d? | 2017-05-05 | 2017-05-05 | 347d | start no earlier than 2017-05-05 |
| 83 | 42.2.5 | Proof and sign off | milestone | 0.88d? | 2017-05-11 | 2017-05-11 | 343.5d | start no earlier than 2017-05-11 |
| 84 | 42.2.6 | Send to print |  | 5.25d? | 2017-05-15 | 2017-05-22 | 337.38d | start no earlier than 2017-05-15 |
| 85 | 42.3 | All Fundraising elements complete | milestone | 0.88d? | 2017-05-22 | 2017-05-22 | 337.38d | start no earlier than 2017-05-22 |
